# Construction Scheduling Template

Schedule from Primavera P6, 2015-10-19 to 2016-08-23, data date 2015-10-19.

## Calendars

- CNT0 - 1 - State Bus. Days: Mon-Fri 08:00-12:00, 13:00-17:00; Sat-Sun off. Exceptions (off unless hours are given): 2015-11-03, 2015-11-11, 2015-11-26, 2015-12-25, 2016-01-01, 2016-01-18, 2016-02-15, 2016-03-25, 2016-05-30, 2016-07-04, 2016-08-05.
- CNT0 - 4 - 7 Day Work Week: Mon-Sun 08:00-12:00, 13:00-17:00.

## Schedule

| ID | WBS | Activity | Type | Duration | Start | Finish | Predecessors | Total float | Calendar | RESP - Responsibility |
| --- | --- | --- | --- | --- | --- | --- | --- | --- | --- | --- |
|  | 0 | **Milestones** |  |  | 2015-10-19 | 2016-08-23 |  |  |  |  |
| M100 |  | Advertise Date | milestone | 0d | 2015-10-19 | 2015-10-19 |  | 0d |  |  |
| M400 |  | Start Design Work (Design/Build only) | milestone | 0d | 2015-10-19 | 2015-10-19 |  | 210d |  |  |
| M480 |  | Complete Design Work (Design/Build only) |  | 0d | 2015-10-19 | 2015-10-19 |  | 210d |  |  |
| M600 |  | Stage __ Complete (Increase by 5) |  | 0d | 2015-10-19 | 2015-10-19 |  | 210d |  |  |
| M700 |  | Interim Completion Date(s) (Increase by 10) |  | 0d | 2015-10-19 | 2015-10-19 |  | 210d |  |  |
| M800 |  | ROW Availability Date (Increase by 5) |  | 0d | 2015-10-19 | 2015-10-19 |  | 210d |  |  |
| M200 |  | Bid Date | milestone | 0d | 2015-11-10 | 2015-11-10 | A100 | 0d |  |  |
| M300 |  | Award Date | milestone | 0d | 2015-12-03 | 2015-12-03 | A200 | 0d |  |  |
| M500 |  | Construction Start Date | milestone | 0d | 2016-02-02 | 2016-02-02 | A300 | 0d |  |  |
| M900 |  | Substantial Completion |  | 0d | 2016-06-24 | 2016-06-24 | C100 | 0d |  |  |
| M950 |  | Completion |  | 0d | 2016-08-23 | 2016-08-23 | F9000 | 0d |  |  |
|  | C | **Construction** |  |  | 2015-10-19 | 2016-08-22 |  |  |  |  |
|  | 00 | **Administrative** |  |  | 2015-10-19 | 2016-02-01 |  |  |  |  |
| A100 |  | Time frame between Advertisement and Bid(Verify) |  | 15d | 2015-10-19 | 2015-11-09 | M100 | 0d |  |  |
| A200 |  | Time frame Between Bid and Award -Verify Duration |  | 15d | 2015-11-10 | 2015-12-02 | M200 | 0d |  |  |
| A300 |  | Time frame Between Award and Construction -Verify |  | 40d | 2015-12-03 | 2016-02-01 | M300 | 0d |  |  |
|  | 01 | **Stage 1** |  |  | 2016-02-02 | 2016-06-23 |  |  |  |  |
|  | 1A | **Stage 1 A** |  |  | 2016-02-02 | 2016-06-23 |  |  |  |  |
| C100 |  | Blank Activity to Show Scheduling WBS |  | 100d | 2016-02-02 | 2016-06-23 | M500 | 0d |  |  |
|  | 1B | **Stage 1 B** |  |  |  |  |  |  |  |  |
|  | 1C | **Stage 1 C** |  |  |  |  |  |  |  |  |
|  | 1D | **Stage 1 D** |  |  |  |  |  |  |  |  |
|  | 02 | **Stage 2** |  |  |  |  |  |  |  |  |
|  | 2A | **Stage 2 A** |  |  |  |  |  |  |  |  |
|  | 2B | **Stage 2 B** |  |  |  |  |  |  |  |  |
|  | 2C | **Stage 2 C** |  |  |  |  |  |  |  |  |
|  | 2D | **Stage 2 D** |  |  |  |  |  |  |  |  |
|  | 03 | **Stage 3** |  |  |  |  |  |  |  |  |
|  | 3A | **Stage 3 A** |  |  |  |  |  |  |  |  |
|  | 3B | **Stage 3 B** |  |  |  |  |  |  |  |  |
|  | 3C | **Stage 3 C** |  |  |  |  |  |  |  |  |
|  | 3D | **Stage 3 D** |  |  |  |  |  |  |  |  |
|  | 04 | **Stage 4** |  |  |  |  |  |  |  |  |
|  | 4A | **Stage 4 A** |  |  |  |  |  |  |  |  |
|  | 4B | **Stage 4 B** |  |  |  |  |  |  |  |  |
|  | 4C | **Stage 4 C** |  |  |  |  |  |  |  |  |
|  | 4D | **Stage 4 D** |  |  |  |  |  |  |  |  |
|  | 05 | **Stage 5** |  |  |  |  |  |  |  |  |
|  | 5A | **Stage 5 A** |  |  |  |  |  |  |  |  |
|  | 5B | **Stage 5 B** |  |  |  |  |  |  |  |  |
|  | 5C | **Stage 5 C** |  |  |  |  |  |  |  |  |
|  | 5D | **Stage 5 D** |  |  |  |  |  |  |  |  |
|  | 10 | **Final Cleanup** |  |  | 2016-06-24 | 2016-08-22 |  |  |  |  |
| F9000 |  | Final Cleanup - Punch list - Submittals |  | 60d | 2016-06-24 | 2016-08-22 | M900 | 0d | CNT0 - 4 - 7 Day Work Week | CONP |

| ID | WBS | Activity | Duration | Start | Finish | Total float |
| --- | --- | --- | --- | --- | --- | --- |
|  | P | **Procurement** |  | 2015-10-19 | 2015-11-17 |  |
|  | CS | **Contractor Submittals (Not Materials)** |  | 2015-10-19 | 2015-11-17 |  |
|  | 01 | **Safety Plan** |  | 2015-10-19 | 2015-11-17 |  |
| PS100 |  | Safety Plan (For Display Purposes) | 20d | 2015-10-19 | 2015-11-17 | 190d |

## Activity codes

| Code | Value | Meaning |
| --- | --- | --- |
| RESP - Responsibility | CONP | Prime Contractor |
